# Projektablaufplan

Schedule from MS Project, 2022-01-10 to 2028-12-18.
Tiefbauamt Winterthur

## Calendars

- Standard: Mon-Fri 08:00-12:00, 13:00-17:00; Sat-Sun off.

## Schedule

| ID | WBS | Task | Duration | Start | Finish | Predecessors | Total slack | Free slack | Constraint | Text1 | Text2 |
| --- | --- | --- | --- | --- | --- | --- | --- | --- | --- | --- | --- |
| 1 | 1 | **Projektname, 11XXX, 70XXX, 50XXX** | 1811d? | 2022-01-10 | 2028-12-18 |  | 0d |  |  |  |  |
| 2 | 1.1 | **3 Projektierung** | 1256d? | 2022-01-10 | 2026-11-02 |  | 0d |  |  | Okt '08 | Nov '09 |
| 3 | 1.1.1 | **31 Vorprojekt** | 440d | 2022-01-10 | 2023-09-15 |  | 0d |  |  |  |  |
| 4 | 1.1.1.1 | Projektstart, Projektadministration | 2w | 2022-01-10 | 2022-01-21 |  | 0d |  | start no earlier than 2022-01-10 |  |  |
| 5 | 1.1.1.2 | Projektübergabe, genehmigte Vorstudie (Phase 21,22) | 2w | 2022-01-24 | 2022-02-04 | 4 | 0d |  |  |  |  |
| 6 | 1.1.1.3 | Projekteröffnung (für projekte ohen Phase 2) | 2w | 2022-02-07 | 2022-02-18 | 5 | 0d |  |  |  |  |
| 7 | 1.1.1.4 | Einforderung Bestellungen inkl. Beurteilung | 4w | 2022-02-21 | 2022-03-18 | 6 | 0d |  |  |  |  |
| 8 | 1.1.1.5 | Startsitzung Vorprojekt | 1w | 2022-03-21 | 2022-03-25 | 7 | 0d |  |  |  |  |
| 9 | 1.1.1.6 | Projektierungskredit, Antrag verfassen | 2w | 2022-03-28 | 2022-04-08 | 8 | 0d |  |  |  |  |
| 10 | 1.1.1.7 | Ausgabebewilligung (SI 2 Wochen, SR 6 Wochen, Stadtparlament 6 Monate) | 6w | 2022-04-11 | 2022-05-20 | 9 | 0d |  |  |  |  |
| 11 | 1.1.1.8 | Submisson Ingenieurleistungen | 12w | 2022-05-23 | 2022-08-12 | 10 | 0d |  |  |  |  |
| 12 | 1.1.1.9 | Vergaben Ingenieurleistungen (4WO DV, 6W SR) | 4w | 2022-08-15 | 2022-09-09 | 11 | 0d |  |  |  |  |
| 13 | 1.1.1.10 | Zustandsuntersuchungen Oberfläche / Kanal / GAL | 12w | 2022-08-15 | 2022-11-04 | 11 | 1596d |  |  |  |  |
| 14 | 1.1.1.11 | Ausarbeitung Vorprojekt Oberfläche | 12w | 2022-09-12 | 2022-12-02 | 12 | 316d | 0d |  |  |  |
| 15 | 1.1.1.12 | UVP / Lärmschutz - Einordnung | 2w | 2022-12-05 | 2022-12-16 | 14 | 316d | 0d |  |  |  |
| 16 | 1.1.1.13 | Störfallachse - Einordnung | 2w | 2022-12-19 | 2022-12-30 | 15 | 1506d | 0d |  |  |  |
| 17 | 1.1.1.14 | Vernehmlasung light Projekt Oberfläche nach Bedarf | 2w | 2023-01-02 | 2023-01-13 | 16 | 1506d | 0d |  |  |  |
| 18 | 1.1.1.15 | Vorbereitung Vorprüfung oder Anhörung (AFM) | 5w | 2023-01-16 | 2023-02-17 | 17 | 1506d | 0d |  |  |  |
| 19 | 1.1.1.16 | Vorprüfung oder Anhörung (AFM) | 3w | 2023-02-20 | 2023-03-10 | 18 | 1506d |  |  |  |  |
| 20 | 1.1.1.17 | evtl. Begehensäusserung (AFM) inkl. Vorbereitung | 8w | 2023-01-16 | 2023-03-10 | 17 | 1506d |  |  |  |  |
| 21 | 1.1.1.18 | Vorbereitung SR-Antrag | 3w | 2022-12-19 | 2023-01-06 | 15 | 316d | 0d |  |  |  |
| 22 | 1.1.1.19 | Zustimmung zum Projekt durch Stadtrat § 13 StrG und § 16 StrG | 4w | 2023-01-09 | 2023-02-03 | 21 | 1531d |  |  |  |  |
| 23 | 1.1.1.20 | Vorbereitung Mitwirkungsverfahren §13 StG | 4w | 2023-01-09 | 2023-02-03 | 21 | 316d | 0d |  |  |  |
| 24 | 1.1.1.21 | Mitwirkungsverfahren §13 StG | 4w | 2023-02-06 | 2023-03-03 | 23 | 316d | 0d |  |  |  |
| 25 | 1.1.1.22 | Beurteilung Einwendungen / Ausarbeitung Bericht | 8w | 2023-03-06 | 2023-04-28 | 24 | 316d | 0d |  |  |  |
| 26 | 1.1.1.23 | Bericht zu den Einwendungen gemäss § 13 StrG | 8w | 2023-05-01 | 2023-06-23 | 25 | 316d | 0d |  |  |  |
| 27 | 1.1.1.24 | Vorprüfung/Stellungnahme SBB im Sinne von 18m EBG | 8w | 2023-06-26 | 2023-08-18 | 26 | 1371d | 0d |  |  |  |
| 28 | 1.1.1.25 | Fertigstellung Vorprojekt Oberfläche | 4w | 2023-08-21 | 2023-09-15 | 27 | 1371d |  |  |  |  |
| 29 | 1.1.1.26 | Ausarbeitung Vorprojekt Kanal- und Werkleitungen | 24w | 2022-09-12 | 2023-02-24 | 12 | 0d |  |  |  |  |
| 30 | 1.1.1.27 | Vernehmlasung light Projekt Kanal nach Bedarf | 2w | 2023-02-27 | 2023-03-10 | 29 | 0d |  |  |  |  |
| 31 | 1.1.1.28 | Projektinfo AWEL | 8w | 2023-03-13 | 2023-05-05 | 30 | 0d |  |  |  |  |
| 32 | 1.1.1.29 | Fertigstellung Vorprojekt Kanal und Werkleitungsbau | 2w | 2023-05-08 | 2023-05-19 | 31 | 0d |  |  |  |  |
| 33 | 1.1.1.30 | Bereinigung Vorprojekt , Berücksichtigung Oberfläche und Werkleitungen, Vorbereitung Vernehmlassung | 4w | 2023-05-22 | 2023-06-16 | 32 | 0d |  |  |  |  |
| 34 | 1.1.1.31 | Vernehmlassung Vorprojekt Oberfläche / Kanal / WL | 4w | 2023-06-19 | 2023-07-14 | 33 | 0d |  |  |  |  |
| 35 | 1.1.1.32 | Verarbeitung Stellungnahmen | 4w | 2023-07-17 | 2023-08-11 | 34 | 0d |  |  |  |  |
| 36 | 1.1.1.33 | Fertigstellung Vorprojekt Strassen- und Kanalbau | 1w | 2023-08-14 | 2023-08-18 | 35 | 0d |  |  |  |  |

| ID | WBS | Task | Duration | Start | Finish | Predecessors | Total slack | Free slack | Text1 | Text2 |
| --- | --- | --- | --- | --- | --- | --- | --- | --- | --- | --- |
| 37 | 1.1.2 | **32 Bauprojekt** | 516d? | 2023-08-21 | 2025-08-11 |  | 0d |  | Okt '08 | Jun '09 |
| 38 | 1.1.2.1 | Projektstart, Projektadministration | 2w | 2023-08-21 | 2023-09-01 | 36 | 0d |  |  |  |
| 39 | 1.1.2.2 | Projekteröffnung (Start Phase 32) | 1d? | 2023-09-04 | 2023-09-04 | 38 | 0d |  |  |  |
| 40 | 1.1.2.3 | Startsitzung Bauprojekt | 1w | 2023-09-05 | 2023-09-11 | 39 | 0d |  |  |  |
| 41 | 1.1.2.4 | Projektierungskredit , Antrag verfassen bei Projektstart ab Phase 32 | 2w | 2023-09-12 | 2023-09-25 | 40 | 0d |  |  |  |
| 42 | 1.1.2.5 | Ausgabefreigabe (SI 2 Wochen, SR 6 Wochen, GGR 6 Monate) | 6w | 2023-09-26 | 2023-11-06 | 41 | 0d |  |  |  |
| 43 | 1.1.2.6 | Submisson Ingenieurleistungen | 12w | 2023-11-07 | 2024-01-29 | 42 | 0d |  |  |  |
| 44 | 1.1.2.7 | Vergaben Ingenieurleistungen | 4w | 2024-01-30 | 2024-02-26 | 43 | 0d |  |  |  |
| 45 | 1.1.2.8 | Bestandesaufnahmen VAW (Oberflächen, best. Bauten, Lage von Grossprofilkanälen, Flusssohlen etc.) | 12w | 2024-02-27 | 2024-05-20 | 44 | 1195d |  |  |  |
| 46 | 1.1.2.9 | Ausarbeitung Bauprojekt Oberfläche | 20w | 2024-02-27 | 2024-07-15 | 44 | 0d |  | Okt '08 | Jan '09 |
| 47 | 1.1.2.10 | Ausarbeitung Signalisations- Markierungsplan | 20w | 2024-02-27 | 2024-07-15 | 44 | 1155d |  |  |  |
| 48 | 1.1.2.11 | Ausarbeitung Bauprojekt Kanal- Werkleitungsbau | 20w | 2024-02-27 | 2024-07-15 | 44 | 0d |  |  |  |
| 49 | 1.1.2.12 | Ausarbeitung KV und KT | 8w | 2024-07-16 | 2024-09-09 | 48 | 0d |  |  |  |
| 50 | 1.1.2.13 | Ausarbeitung UVP / Lärmschutz | 8w | 2024-07-16 | 2024-09-09 | 48, 46 | 0d |  |  |  |
| 51 | 1.1.2.14 | Ausarbeitung Störfallachse | 8w | 2024-07-16 | 2024-09-09 | 48, 46 | 1085d | 0d |  |  |
| 52 | 1.1.2.15 | Fertigstellung Bauprojekt Strassen- Kanal und Werkleitungsbau | 6w | 2024-09-10 | 2024-10-21 | 51 | 1085d |  |  |  |
| 53 | 1.1.2.16 | Erwerb von Grund und Rechten / Vereinbarungen erwirken | 2w | 2024-09-10 | 2024-09-23 | 50 | 25d | 0d |  |  |
| 54 | 1.1.2.17 | Vernehmlassung | 5w | 2024-09-24 | 2024-10-28 | 53 | 25d |  | Jan '09 | Feb '09 |
| 55 | 1.1.2.18 | Begehrensäusserung AfM §45 | 12w | 2024-09-10 | 2024-12-02 | 49, 26 | 0d |  | Jan '09 | Feb '09 |
| 56 | 1.1.2.19 | Zusammenfassende Beurteilung der Umweltverträglichkeit | 12w | 2024-09-10 | 2024-12-02 | 50 | 0d |  |  |  |
| 57 | 1.1.2.20 | Verarbeitung Stellungnahmen | 8w | 2024-12-03 | 2025-01-27 | 54, 56, 55 | 0d |  | Feb '09 | Mrz '09 |
| 58 | 1.1.2.21 | Zustimmung zum Projekt durch Stadtrat (neue Verkehrsanordnung) , Information zum Projekt Stadtrat (wesentlche Projektänderungen) | 4w | 2025-01-28 | 2025-02-24 | 57 | 0d |  | Mrz '09 | Apr '09 |
| 59 | 1.1.2.22 | Vorbereitung Planauflage §16 StG , § 18a WWG und Art. 36a GSch, EBG 18m, Rodung (Wald) Art. 5 WaG, Waldabstand § 262 PBG | 4w | 2025-02-25 | 2025-03-24 | 58 | 0d |  |  |  |
| 60 | 1.1.2.23 | Planauflage §16 StG, Publikation der neuen Verkehranordnung, § 18a WWG und Art. 36a GSch, EBG 18m, Rodung (Wald) Art. 5 WaG, Waldabstand § 262 PBG | 4w | 2025-03-25 | 2025-04-21 | 59 | 0d |  | Apr '09 | Mai '09 |
| 61 | 1.1.2.24 | Bearbeitung Einsprachen, Rückzug Einsprachen | 12w | 2025-04-22 | 2025-07-14 | 60 | 0d |  |  |  |
| 62 | 1.1.2.25 | Fertigstellung Bauprojekt Strassen- und Kanalbau | 4w | 2025-07-15 | 2025-08-11 | 61 | 0d |  |  |  |

| ID | WBS | Task | Type | Duration | Start | Finish | Predecessors | Total slack | Free slack | Text1 | Text2 |
| --- | --- | --- | --- | --- | --- | --- | --- | --- | --- | --- | --- |
| 63 | 1.1.2.26 | **Kostenteiler Kanton ZH** |  | 60d | 2025-04-22 | 2025-07-14 |  | 895d |  |  |  |
| 64 | 1.1.2.26.1 | Kostenteilerplan erstellen |  | 4w | 2025-04-22 | 2025-05-19 | 60 | 895d | 0d |  |  |
| 65 | 1.1.2.26.2 | Kostenteilerplan mit Kanton ZH besprechen |  | 4w | 2025-05-20 | 2025-06-16 | 64 | 895d | 0d |  |  |
| 66 | 1.1.2.26.3 | Kostenteilertabelle erstellen und freigeben |  | 4w | 2025-06-17 | 2025-07-14 | 65 | 895d |  |  |  |
| 67 | 1.1.3 | **33 Bewilligungsverfahren** |  | 320d | 2025-08-12 | 2026-11-02 |  | 0d |  | Mai '09 | Nov '09 |
| 68 | 1.1.3.1 | **Projektfestsetzung** |  | 60d | 2025-08-12 | 2025-11-03 |  | 0d |  |  |  |
| 69 | 1.1.3.1.1 | Antrag SR erstellen/freigeben |  | 4w | 2025-08-12 | 2025-09-08 | 62 | 0d |  |  |  |
| 70 | 1.1.3.1.2 | Mitberichtsverfahren SR |  | 4w | 2025-09-09 | 2025-10-06 | 69 | 0d |  |  |  |
| 71 | 1.1.3.1.3 | Beschluss SR - Projektfestsetzung inkl. Rekursfrist |  | 4w | 2025-10-07 | 2025-11-03 | 70 | 0d |  |  |  |
| 72 | 1.1.3.2 | **Kreditbewilligung** |  | 115d | 2025-11-04 | 2026-04-13 |  | 0d |  |  |  |
| 73 | 1.1.3.2.1 | Vorbereitung und Einreichung |  | 4w | 2025-11-04 | 2025-12-01 | 71 | 115d | 0d |  |  |
| 74 | 1.1.3.2.2 | Mitberichtsverfahren Genehmigung SI / DV |  | 2w | 2025-12-02 | 2025-12-15 | 73 | 135d | 0d |  |  |
| 75 | 1.1.3.2.3 | Genehmigung SI / Vorsteher-in |  | 2w | 2025-12-16 | 2025-12-29 | 74 | 135d |  |  |  |
| 76 | 1.1.3.2.4 | Mitberichtsverfahren Genehmigung SR |  | 4w | 2025-12-02 | 2025-12-29 | 73 | 115d | 0d |  |  |
| 77 | 1.1.3.2.5 | Genehmigung SR |  | 4w | 2025-12-30 | 2026-01-26 | 76 | 115d |  |  |  |
| 78 | 1.1.3.2.6 | Weisung Stadtparlament erstellen und einreichen |  | 4w | 2025-11-04 | 2025-12-01 | 71 | 0d |  |  |  |
| 79 | 1.1.3.2.7 | Mitberichstverfahren SR Weisung |  | 4w | 2025-12-02 | 2025-12-29 | 78 | 0d |  |  |  |
| 80 | 1.1.3.2.8 | Beschluss SR Weisung |  | 2w | 2025-12-30 | 2026-01-12 | 79 | 0d |  |  |  |
| 81 | 1.1.3.2.9 | SBK Lesungen |  | 12w | 2026-01-13 | 2026-04-06 | 80 | 0d |  |  |  |
| 82 | 1.1.3.2.10 | Genehmigung Stadparlament |  | 1w | 2026-04-07 | 2026-04-13 | 81 | 0d |  | Jul '09 | Sep '09 |
| 83 | 1.1.3.2.11 | Volksabstimmung (separat) | milestone | 0w | 2026-04-13 | 2026-04-13 | 82 | 60d |  |  |  |
| 84 | 1.1.3.3 | **Projektgenehmigung Kanton ZH** |  | 80d | 2026-04-14 | 2026-08-03 |  | 0d |  |  |  |
| 85 | 1.1.3.3.1 | Antrag erstellen und einreichen |  | 4w | 2026-04-14 | 2026-05-11 | 82 | 0d |  |  |  |
| 86 | 1.1.3.3.2 | Projektgenehmigung §45 StG inkl. RBB |  | 8w | 2026-05-12 | 2026-07-06 | 85, 71 | 0d |  | Sep '09 | Nov '09 |
| 87 | 1.1.3.3.3 | Bewilligung kantonale Leitstelle Baudirektion ZH (wenn mehrere Fachstellen betroffen sind ARE-RP-Landschaft, ARE-Archäologie, ARE Denkmalpflege, AWA-Arbeitnehmerschutz ALN-Wald, ALN-FaBo, AWEL-Wasserbau, AWEL-Altlasten, AWEL-Gewässerschutz SE und GWV |  | 12w | 2026-05-12 | 2026-08-03 | 85 | 620d |  |  |  |

| ID | WBS | Task | Duration | Start | Finish | Predecessors | Total slack | Free slack | Text1 | Text2 |
| --- | --- | --- | --- | --- | --- | --- | --- | --- | --- | --- |
| 88 | 1.1.3.4 | **Bewilligung AWEL** | 120d | 2025-08-12 | 2026-01-26 |  | 755d |  |  |  |
| 89 | 1.1.3.4.1 | Antrag erstellen und einreichen | 4w | 2025-08-12 | 2025-09-08 | 62 | 795d | 40d |  |  |
| 90 | 1.1.3.4.2 | Bewilligung AWEL | 12w | 2025-11-04 | 2026-01-26 | 89, 71 | 755d |  |  |  |
| 91 | 1.1.3.5 | **SBB §18m EBG** | 80d | 2025-08-12 | 2025-12-01 |  | 795d |  |  |  |
| 92 | 1.1.3.5.1 | Erstellung und Einreichung Antrag inkl. Projektdossier | 4w | 2025-08-12 | 2025-09-08 | 62 | 795d | 0d |  |  |
| 93 | 1.1.3.5.2 | Durchführung §18m EBG | 12w | 2025-09-09 | 2025-12-01 | 92 | 795d |  |  |  |
| 94 | 1.1.3.6 | **Aggloprogramm** | 145d | 2026-04-14 | 2026-11-02 |  | 555d |  |  |  |
| 95 | 1.1.3.6.1 | Beitraggesuch erarbeiten | 4w | 2026-04-14 | 2026-05-11 | 82, 71 | 555d | 0d |  |  |
| 96 | 1.1.3.6.2 | Beitraggesucht einreichen | 1w | 2026-05-12 | 2026-05-18 | 95, 85 | 555d | 0d |  |  |
| 97 | 1.1.3.6.3 | Finanzierungsvereinbarung AGGLO | 24w | 2026-05-19 | 2026-11-02 | 96 | 555d |  |  |  |
| 98 | 1.2 | **4 Ausschreibung** | 200d | 2026-04-14 | 2027-01-18 |  | 15d |  | Mrz '09 | Nov '09 |
| 99 | 1.2.1 | **41 Ausschreibung, Offertvergleich, Vergabe** | 200d | 2026-04-14 | 2027-01-18 |  | 15d |  | Mrz '09 | Nov '09 |
| 100 | 1.2.1.1 | Ingenieur: Vergabe Realisiereung | 1w | 2026-04-14 | 2026-04-20 | 82 | 695d |  |  |  |
| 101 | 1.2.1.2 | Startsitzung Submission | 1w | 2026-04-14 | 2026-04-20 | 82 | 15d | 0d |  |  |
| 102 | 1.2.1.3 | Submissionsunterlagen | 8w | 2026-04-21 | 2026-06-15 | 101 | 15d |  | Apr '09 | Jun '09 |
| 103 | 1.2.1.4 | Submission | 12w | 2026-07-07 | 2026-09-28 | 102, 75, 77, 82, 83, 86 | 0d |  | Jun '09 | Jul '09 |
| 104 | 1.2.1.5 | Vergabe Bauarbeiten, Einsprachefrist | 12w | 2026-09-29 | 2026-12-21 | 103 | 0d |  | Okt '09 | Okt '09 |
| 105 | 1.2.1.6 | Werkvertrag | 4w | 2026-12-22 | 2027-01-18 | 104 | 0d |  | Okt '09 | Nov '09 |
| 106 | 1.3 | **5 Realisierung** | 700d | 2026-04-14 | 2028-12-18 |  | 0d |  | Jun '09 | Mrz '11 |
| 107 | 1.3.1 | **51 Ausführungsprojekt** | 275d | 2026-04-14 | 2027-05-03 |  | 425d |  | Jun '09 | Sep '09 |
| 108 | 1.3.1.1 | Ausführungsprojekt | 55w | 2026-04-14 | 2027-05-03 | 82 | 425d |  | Jun '09 | Sep '09 |
| 109 | 1.3.1.2 | **Publikation temp. Verkehranordnung** | 205d | 2026-07-07 | 2027-04-20 |  | 435d |  |  |  |
| 110 | 1.3.1.2.1 | Signalisations-Markierungsplan vorbereiten/freigeben | 4w | 2026-07-07 | 2026-08-03 | 62, 71, 86 | 540d | 0d |  |  |
| 111 | 1.3.1.2.2 | Zustimmung zur Publikation (AVE) | 4w | 2026-08-04 | 2026-08-31 | 110 | 540d | 105d |  |  |
| 112 | 1.3.1.2.3 | Publikation temp. Verkehranordnung inkl. Rekursfirst | 12w | 2027-01-26 | 2027-04-20 | 111, 104, 117SF | 435d |  |  |  |

| ID | WBS | Task | Duration | Start | Finish | Predecessors | Total slack | Text1 | Text2 |
| --- | --- | --- | --- | --- | --- | --- | --- | --- | --- |
| 113 | 1.3.2 | **52 Ausführung** | 385d | 2027-01-19 | 2028-07-10 |  | 0d | Okt '09 | Nov '10 |
| 114 | 1.3.2.1 | Startsitzung Bau | 1w | 2027-01-19 | 2027-01-25 | 105 | 0d | Okt '09 | Okt '09 |
| 115 | 1.3.2.2 | Bauvorbereitung / AVOR | 8w | 2027-01-26 | 2027-03-22 | 114 | 0d | Okt '09 | Nov '09 |
| 116 | 1.3.2.3 | Anwohnerinformation | 2w | 2027-03-23 | 2027-04-05 | 115 | 0d | Okt '09 | Nov '09 |
| 117 | 1.3.2.4 | Bauausführung | 64w | 2027-04-20 | 2028-07-10 | 116FS+2w | 0d | Nov '09 | Nov '09 |
| 118 | 1.3.3 | **53 Inbetriebnahme, Abschluss** | 115d | 2028-07-11 | 2028-12-18 |  | 0d | Dez '10 | Mrz '11 |
| 119 | 1.3.3.1 | Technische Abnahme | 2w | 2028-07-11 | 2028-07-24 | 117 | 0d |  |  |
| 120 | 1.3.3.2 | Abnahme, Übergabe | 1w | 2028-07-25 | 2028-07-31 | 119 | 0d | Dez '10 | Dez '10 |
| 121 | 1.3.3.3 | Abschluss | 20w | 2028-08-01 | 2028-12-18 | 120 | 0d | Dez '10 | Mrz '11 |
