# SubmBauBeilageBauprogramm

Schedule from MS Project, 2019-09-16 to 2020-06-01.
Tiefbauamt Winterthur

## Calendars

- Standard: Mon-Fri 08:00-12:00, 13:00-17:00; Sat-Sun off.

## Schedule

| ID | WBS | Task | Type | Duration | Start | Finish | Predecessors | Total slack | Free slack | Constraint | Work |
| --- | --- | --- | --- | --- | --- | --- | --- | --- | --- | --- | --- |
| 1 | 1 | **Strassenname, 50XXX und 70XXX** |  | 186d | 2019-09-16 | 2020-06-01 |  | 0d |  |  | 12h |
| 3 | 1.1 | Baubeginn 2019 | milestone | 0d | 2019-09-16 | 2019-09-16 |  | 120d | 0d | start no earlier than 2019-09-16 |  |
| 4 | 1.2 | **Vorarbeiten** |  | 6d | 2019-09-16 | 2019-09-23 | 3 | 120d | 0d |  |  |
| 5 | 1.2.1 | Baustelleneinrichtung |  | 2d | 2019-09-16 | 2019-09-17 |  | 120d | 0d | start no earlier than 2005-06-02 |  |
| 6 | 1.2.2 | Abbrüche/Demontagen |  | 4d | 2019-09-18 | 2019-09-23 | 5 | 120d |  |  |  |
| 7 | 1.3 | **Mittlere Gerberstrasse** |  | 33d | 2019-09-24 | 2019-11-07 | 4 | 120d | 0d |  | 12h |
| 8 | 1.3.1 | G/W |  | 6d | 2019-09-24 | 2019-10-01 |  | 120d | 0d |  |  |
| 9 | 1.3.2 | Kanalersatz |  | 15d | 2019-10-02 | 2019-10-22 | 8 | 120d | 0d |  | 12h |
| 10 | 1.3.3 | Hausanschlussleitungen |  | 7d | 2019-10-23 | 2019-10-31 | 9 | 120d | 0d |  |  |
| 11 | 1.3.4 | Strassenbau |  | 5d | 2019-11-01 | 2019-11-07 | 10 | 120d |  |  |  |
| 12 | 1.4 | **Untere Gerberstrasse** |  | 27d | 2019-11-08 | 2019-12-16 | 7 | 120d |  |  |  |
| 13 | 1.4.1 | Kanalersatz |  | 15d | 2019-11-08 | 2019-11-28 |  | 120d | 0d |  |  |
| 14 | 1.4.2 | Hausanschlussleitungen |  | 7d | 2019-11-29 | 2019-12-09 | 13 | 120d | 0d |  |  |
| 15 | 1.4.3 | Strassenbau |  | 5d | 2019-12-10 | 2019-12-16 | 14 | 120d |  |  |  |
| 17 | 1.5 | Baubeginn 2020 | milestone | 0d | 2020-03-06 | 2020-03-06 |  | 0d |  | start no earlier than 2020-03-06 |  |
| 18 | 1.6 | **Färberstrasse** |  | 40d | 2020-03-06 | 2020-04-30 | 17 | 0d |  |  |  |
| 19 | 1.6.1 | Kanalersatz |  | 15d | 2020-03-06 | 2020-03-26 |  | 0d |  |  |  |
| 20 | 1.6.2 | Hausanschlussleitungen |  | 10d | 2020-03-27 | 2020-04-09 | 19 | 0d |  |  |  |
| 21 | 1.6.3 | EW |  | 8d | 2020-04-10 | 2020-04-21 | 20 | 0d |  |  |  |
| 22 | 1.6.4 | Strassenbau |  | 7d | 2020-04-22 | 2020-04-30 | 21 | 0d |  |  |  |
| 23 | 1.7 | **Untere Schleifestrasse** |  | 22d | 2020-05-01 | 2020-06-01 | 18 | 0d |  |  |  |
| 24 | 1.7.1 | Kanalersatz |  | 8d | 2020-05-01 | 2020-05-12 |  | 0d |  |  |  |
| 25 | 1.7.2 | Hausanschlussleitungen |  | 5d | 2020-05-13 | 2020-05-19 | 24 | 0d |  |  |  |
| 26 | 1.7.3 | Strassenbau |  | 4d | 2020-05-20 | 2020-05-25 | 25 | 0d |  |  |  |
| 28 | 1.7.4 | Deckbelag |  | 5d | 2020-05-26 | 2020-06-01 | 26 | 0d |  |  |  |
